# aikataulu

Schedule from MS Project, 2003-01-31 to 2003-05-23.
University of Jyväskylä

## Calendars

- Standard: Mon-Fri 08:00-12:00, 13:00-17:00; Sat-Sun off.

## Resources

| Resource |
| --- |
| kaikki |
| HM |
| PP |
| SB |
| AK, |
| SB,AK,HM,PP |
| PP,SB |
| SB,AK |

## Schedule

| ID | Task | Duration | Start | Finish | Baseline start | Baseline finish | Baseline duration | Total slack | Constraint | Resources | Work |
| --- | --- | --- | --- | --- | --- | --- | --- | --- | --- | --- | --- |
| 1 | aiheeseen tutustuminen | 11d | 2003-01-31 | 2003-02-14 | 2003-01-31 | 2003-03-12 | 29d | 70d | start no earlier than 2003-01-31 | SB,AK,HM,PP | 88h |
| 2 | projektisuunnitelma | 20d? | 2003-02-17 | 2003-03-14 | 2003-02-17 | 2003-03-07 | 15d? | 50d | start no earlier than 2003-02-17 | HM | 160h |
| 3 | vaatimusmäärittely | 15d? | 2003-02-24 | 2003-03-14 | 2003-02-17 | 2003-03-07 | 15d? | 50d | finish no earlier than 2003-03-14 | PP,SB | 120h |
| 4 | sovellussuunnitelma | 15d? | 2003-03-03 | 2003-03-21 | 2003-02-24 | 2003-03-20 | 19d? | 45d | start no earlier than 2003-03-03 | SB,AK,HM,PP | 120h |
| 5 | toteutus: käyttöliittymä ja kontrolliluokat | 20d? | 2003-03-17 | 2003-04-11 | 2003-03-17 | 2003-04-25 | 30d? | 30d | finish no earlier than 2003-04-11 | SB,AK | 160h |
| 6 | toteutus: terminaali ja lokiluokat | 20d? | 2003-03-17 | 2003-04-11 | 2003-03-17 | 2003-04-25 | 30d? | 30d | finish no earlier than 2003-04-11 | PP | 160h |
| 7 | toteutus: kommunikointiluokat | 20d? | 2003-03-17 | 2003-04-11 | 2003-03-17 | 2003-04-25 | 30d? | 30d | finish no earlier than 2003-04-11 | HM | 160h |
| 8 | viimeistely: käyttöliittymä ja kontrolliluokat | 10d? | 2003-04-14 | 2003-04-25 |  |  |  | 20d | finish no earlier than 2003-04-25 |  |  |
| 9 | viimeistely: terminaali ja lokiluokat | 10d? | 2003-04-14 | 2003-04-25 | 2003-03-17 | 2003-04-25 | 30d? | 20d | start no earlier than 2003-04-14 | PP | 80h |
| 10 | viimeistely: kommunikointiluokat | 10d? | 2003-04-14 | 2003-04-25 | 2003-03-17 | 2003-04-25 | 30d? | 20d | start no earlier than 2003-04-14 | HM | 80h |
| 11 | sovelluksen testaus | 16d? | 2003-04-18 | 2003-05-09 | 2003-04-18 | 2003-05-09 | 16d? | 10d | finish no earlier than 2003-05-09 | SB,AK,HM,PP | 128h |
| 12 | projektiraportti | 21d? | 2003-04-25 | 2003-05-23 | 2003-04-25 | 2003-05-16 | 16d? | 0d | finish no earlier than 2003-05-23 | SB,AK,HM,PP | 168h |
| 13 | sovellusraportti | 21d? | 2003-04-25 | 2003-05-23 | 2003-04-25 | 2003-05-16 | 16d? | 0d | finish no earlier than 2003-05-23 | SB,AK,HM,PP | 168h |

Notes:
- 1: dsfdsfedffdsd
